# online-installation-point8-v2

Schedule from MS Project, 2005-01-10 to 2007-08-13, status date 2002-06-20, A marks actual dates.
CERN

## Calendars

- Standard: Mon-Fri 08:00-12:00, 13:00-17:00; Sat-Sun off. Exceptions (off unless hours are given): 2005-12-19 to 2005-12-20, 2005-12-21 to 2005-12-22 08:00-12:00, 13:00-17:00, 2005-12-23, 2005-12-26 to 2005-12-30, 2006-01-02 to 2006-01-06, 2006-12-25 to 2006-12-29, 2007-01-01 to 2007-01-05.

## Schedule

| ID | WBS | Task | Type | Duration | Start | Finish | Predecessors | Complete | Remaining | Total slack | Free slack | Constraint |
| --- | --- | --- | --- | --- | --- | --- | --- | --- | --- | --- | --- | --- |
| 1 | 1 | **LHCb** |  | 653d? | 2005-01-10 A | 2007-08-13 |  | 27% | 479.82d? | 0d |  |  |
| 2 | 1.1 | **ONLINE Installation and Comissioning** |  | 653d? | 2005-01-10 A | 2007-08-13 |  | 27% | 476.59d? | 0d |  |  |
| 3 | 1.1.1 | Fibre installation SX85 to UX85 (PZ) |  | 1w | 2005-01-10 A | 2005-01-14 A |  | 100% |  |  |  | start no earlier than 2005-01-10 |
| 4 | 1.1.2 | Ethernet cabling in UX85 |  | 14.8w? | 2005-02-01 A | 2005-05-13 |  | 66% | 5.03w? | 563d |  | start no earlier than 2005-02-01 |
| 5 | 1.1.3 | Additional/Recabling for 1MHz |  | 23.6w | 2006-04-15 A | 2006-09-27 |  | 46% | 12.8w | 218d | 40d | finish no earlier than 2006-06-15 |
| 6 | 1.1.4 | 1 MHz cabling ready for detector comissioning | milestone | 1d | 2006-08-07 | 2006-08-07 | 5SS+8w |  |  | 255d |  | finish no earlier than 2006-08-07 |
| 7 | 1.1.5 | Ethernet cabling outside D1 to D3 (GPN, TN, ECS) |  | 4w? | 2006-08-08 | 2006-09-04 |  |  |  | 229d | 129d | finish no earlier than 2006-09-04 |
| 8 | 1.1.6 | **DAQ Installation and Commissioning** |  | 407d? | 2005-12-22 | 2007-08-13 |  |  |  | 0d |  |  |
| 9 | 1.1.6.1 | DAQ ready for sub-detector comissioning | milestone | 1w | 2006-03-20 | 2006-03-24 |  |  |  | 344d | 0d | finish no earlier than 2006-03-24 |
| 10 | 1.1.6.2 | DAQ ready for complete readout | milestone | 0d | 2006-03-24 | 2006-03-24 | 9 |  |  | 351d |  |  |
| 11 | 1.1.6.3 | **Control Room and Computer room SX85** |  | 407d? | 2005-12-22 | 2007-08-13 |  |  |  | 0d |  |  |
| 12 | 1.1.6.3.1 | Networking in SX85 ready | milestone | 0.2w | 2005-12-22 | 2005-12-22 |  |  |  | 399d | 197d | finish no earlier than 2005-12-22 |
| 13 | 1.1.6.3.2 | Installation of workplaces in control room |  | 8w? | 2006-10-04 | 2006-11-28 | 30, 31, 32, 36 |  |  | 174d |  | start no earlier than 2006-09-10 |
| 14 | 1.1.6.3.3 | Install "ATLAS rack-cooler" rack row |  | 1w | 2006-12-18 | 2006-12-22 | 16FS+2w |  |  | 156d |  | start no earlier than 2006-12-16 |
| 15 | 1.1.6.3.4 | **Cooling and Ventilation for SX85** |  | 282d | 2006-06-30 | 2007-08-13 |  |  |  | 0d |  |  |
| 16 | 1.1.6.3.4.1 | Piping |  | 1w | 2006-06-30 | 2006-07-06 |  |  |  | 261d | 0d | start no earlier than 2006-06-30 |
| 17 | 1.1.6.3.4.2 | Connection to chiller and tests |  | 1w | 2006-07-21 | 2006-07-27 | 16FS+2w |  |  | 261d |  |  |
| 18 | 1.1.6.3.4.3 | CV for SX85 operational | milestone | 1d | 2007-08-13 | 2007-08-13 | 16, 17 |  |  | 0d |  | start no earlier than 2007-08-13 |
| 19 | 1.1.7 | **Event Filter Farm installation** |  | 530d? | 2005-02-02 A | 2007-03-16 |  | 40% | 317.2d? | 106d |  |  |
| 20 | 1.1.7.1 | Refurbishment and alignment of racks |  | 3w | 2005-02-02 A | 2005-02-22 A |  | 100% |  |  |  | start no earlier than 2005-02-02 |
| 21 | 1.1.7.2 | Rack-cooler installation |  | 8w | 2005-06-06 A | 2005-07-29 |  | 95% | 0.4w | 508d |  | start no earlier than 2005-06-06 |
| 22 | 1.1.7.3 | Fire extinction system tests | milestone | 56d | 2005-10-03 | 2005-12-21 |  |  |  | 406d | 6d | start no earlier than 2005-10-03 |
| 23 | 1.1.7.4 | Hi-Fog decision | milestone | 0.2w? | 2006-01-16 | 2006-01-16 | 22 |  |  | 400d |  | finish no earlier than 2006-01-16 |
| 24 | 4.4.8.6 | Pre-series of farm PCs for comissioning |  | 4w? | 2007-02-19 | 2007-03-16 |  |  |  | 100d | 0d | start no earlier than 2007-02-19 |

| ID | WBS | Task | Type | Duration | Start | Finish | Predecessors | Complete | Remaining | Total slack | Free slack | Constraint |
| --- | --- | --- | --- | --- | --- | --- | --- | --- | --- | --- | --- | --- |
| 25 | 1.1.8 | **D2 installation** |  | 214d? | 2006-03-01 A | 2007-01-08 |  | 7% | 198.85d? | 155d |  |  |
| 26 | 1.1.8.1 | Finish rack-cooler installation and pressure tests |  | 5.4w? | 2006-06-01 A | 2006-07-07 |  | 44% | 3.02w? | 276d |  | finish no earlier than 2006-07-07 |
| 27 | 1.1.8.2 | Finalise EDMS note & webpage for DCS PC racks |  | 16.6w | 2006-03-01 A | 2006-06-23 |  | 1% | 16.46w | 286d |  | finish no earlier than 2006-06-23 |
| 28 | 1.1.8.3 | Install LHCb U bars in racks |  | 3d | 2006-07-10 | 2006-07-12 |  |  |  | 273d |  | start no earlier than 2006-07-10 |
| 29 | 1.1.8.4 | Install power barettes in D2 |  | 1w? | 2006-07-17 | 2006-07-21 |  |  |  | 266d |  | start no earlier than 2006-07-17 |
| 30 | 1.1.8.5 | Install Farm Control PCs |  | 2w? | 2006-09-06 | 2006-09-19 | 44 |  |  | 184d | 10d | start no earlier than 2006-09-01 |
| 31 | 1.1.8.6 | Install CCPC Control PCs |  | 1w? | 2006-09-06 | 2006-09-12 | 44 |  |  | 189d | 15d | start no earlier than 2006-08-15 |
| 32 | 1.1.8.7 | Install DCSPCs |  | 4w? | 2006-09-06 | 2006-10-03 | 44 |  |  | 174d | 0d | start no earlier than 2006-07-03 |
| 33 | 1.1.8.8 | Monitoring Farm (D2A01 - D2A09) |  | 5w | 2006-11-21 | 2007-01-08 |  |  |  | 155d |  | start no earlier than 2006-11-21 |
| 34 | 1.1.9 | **D1 Installation** |  | 54d? | 2006-07-17 | 2006-09-28 |  |  |  | 204d |  |  |
| 35 | 1.1.9.1 | Remaining rails (with Summerstudents) |  | 1w? | 2006-07-17 | 2006-07-21 |  |  |  | 204d | 0d | start no earlier than 2006-07-17 |
| 36 | 1.1.9.2 | Install Control Switches (HP2650) |  | 12d | 2006-08-07 | 2006-08-22 | 35FS+2w |  |  | 204d | 30d |  |
| 37 | 1.1.9.3 | Test installation of 1 farmrack |  | 1w? | 2006-08-16 | 2006-08-22 |  |  |  | 234d | 17d | start no earlier than 2006-08-16 |
| 38 | 1.1.9.4 | Install DAQ switches (HP3400) |  | 2w? | 2006-09-01 | 2006-09-14 |  |  |  | 217d | 0d | start no earlier than 2006-09-01 |
| 39 | 1.1.9.5 | Pre-install patch-cables |  | 2w | 2006-09-15 | 2006-09-28 | 37, 38 |  |  | 217d |  |  |
| 40 | 1.1.10 | **Computing Infrastructure** |  | 37d? | 2006-07-17 | 2006-09-05 |  |  |  | 174d | 20d |  |
| 41 | 1.1.10.1 | Quattuor server / RPM repo / Kickstart server (Linux) |  | 2d? | 2006-09-01 | 2006-09-04 |  |  |  | 174d | 0d | start no earlier than 2006-09-01 |
| 42 | 1.1.10.2 | Windows install server |  | 2d? | 2006-09-01 | 2006-09-04 |  |  |  | 174d | 0d | start no earlier than 2006-09-01 |
| 43 | 1.1.10.3 | DNS, login, homedirectories, dhcp , ntp, gateways |  | 1w? | 2006-07-17 | 2006-07-21 |  |  |  | 205d | 31d | start no earlier than 2006-07-17 |
| 44 | 1.1.10.4 | Software Installation Infrastructure ready | milestone | 1d | 2006-09-05 | 2006-09-05 | 41, 42, 43 |  |  | 174d | 0d |  |
| 45 | 1.2 | ECS ready for sub-detector commissioning | milestone | 1w | 2006-10-04 | 2006-10-10 | 31, 32, 40 |  |  | 202d | 0d | start no earlier than 2005-12-05 |
| 46 | 1.3 | Online System Ready for sub-detector commissioning |  | 0.2w | 2006-10-11 | 2006-10-11 | 12, 9, 45 |  |  | 202d | 102d | start no earlier than 2006-01-30 |
| 47 | 1.4 | Online System ready for global comissioning | milestone | 1w | 2007-03-19 | 2007-03-23 | 46, 24, 7 |  |  | 100d | 50d | start no earlier than 2006-08-28 |
| 48 | 4.8 | Online System Ready for LHC Startup |  | 1d | 2007-06-04 | 2007-06-04 | 47 |  |  | 50d |  | start no earlier than 2007-06-04 |
